# Kelompok 100

Schedule from MS Project, 2007-06-02 to 2007-06-13.
Antique Furniture
Doggy Co.Ltd
Penjadwalan produksi Doggy Co, Ltd, kelompok 100

## Calendars

- Standard: Mon-Thu 07:00-12:00, 13:00-15:00; Fri 07:00-11:30, 13:00-15:00; Sat 07:00-12:00; Sun off.

## Resources

| Resource | Unit |
| --- | --- |
| Meja ukur |  |
| pak Ali |  |
| multiplex | lembar |
| M. RAS |  |
| pak Bom |  |
| M. Jointer |  |
| pak Cus |  |
| kayu sungkai | batang |
| Meja rakit |  |
| pak Dul |  |
| lem, paku | kg |

## Schedule

| ID | WBS | Task | Duration | Start | Finish | Predecessors | Baseline start | Baseline finish | Baseline duration | Total slack | Free slack | Resources | Work |
| --- | --- | --- | --- | --- | --- | --- | --- | --- | --- | --- | --- | --- | --- |
| 1 | 1 | **Batch 1 (10 unit)** | 1.64d | 2007-06-02 | 2007-06-05 |  | 2007-06-02 | 2007-06-05 | 1.89d | 0d |  |  | 47.44h |
| 2 | 1.1 | **Komponen X** | 0.75d | 2007-06-02 | 2007-06-04 |  | 2007-06-02 | 2007-06-04 | 0.75d | 0d |  |  | 20h |
| 3 | 1.1.1 | Ukur komponen | 200min | 2007-06-02 | 2007-06-02 |  | 2007-06-02 | 2007-06-02 | 200min | 0d |  | Meja ukur; pak Ali; multiplex [1 lembar] | 6.67h |
| 4 | 1.1.2 | Potong | 150min | 2007-06-02 | 2007-06-02 | 3FF+30min | 2007-06-02 | 2007-06-02 | 150min | 0d |  | M. RAS; pak Bom | 5h |
| 5 | 1.1.3 | Penyikuan | 250min | 2007-06-02 | 2007-06-04 | 4SS+30min | 2007-06-02 | 2007-06-04 | 250min | 0d |  | M. Jointer; pak Cus | 8.33h |
| 6 | 1.2 | **Komponen Y** | 1.19d | 2007-06-02 | 2007-06-05 |  | 2007-06-02 | 2007-06-05 | 1.44d | 0d |  |  | 22.44h |
| 7 | 1.2.1 | Ukur komponen | 200min | 2007-06-02 | 2007-06-04 | 3 | 2007-06-02 | 2007-06-04 | 200min | 0.3d | 0d | Meja ukur; pak Ali; kayu sungkai [1 batang] | 6.67h |
| 8 | 1.2.2 | Penyikuan | 533.3min | 2007-06-04 | 2007-06-05 | 7SS+15min, 5 | 2007-06-04 | 2007-06-05 | 533.3min | 0d |  | M. Jointer; pak Cus | 15.78h |
| 9 | 1.3 | **Produk ZZZ** | 0.31d | 2007-06-04 | 2007-06-05 |  | 2007-06-05 | 2007-06-05 | 0.31d | 6.52d |  |  | 5h |
| 10 | 1.3.1 | Rakit dan inspeksi | 150min | 2007-06-04 | 2007-06-05 | 7FF+15min, 8FF+15min | 2007-06-05 | 2007-06-05 | 150min | 6.52d |  | Meja rakit; pak Dul; lem, paku [1 kg] | 5h |
| 11 | 2 | **Batch 2 (20 unit)** | 3.32d | 2007-06-04 | 2007-06-08 |  | 2007-06-04 | 2007-06-08 | 3.63d | 0.44d |  |  | 92.89h |
| 12 | 2.1 | **Komponen X** | 1.57d | 2007-06-04 | 2007-06-06 |  | 2007-06-04 | 2007-06-05 | 1.38d | 0d |  |  | 38h |
| 13 | 2.1.1 | Ukur komponen | 400min | 2007-06-04 | 2007-06-05 | 7 | 2007-06-04 | 2007-06-05 | 400min | 0.44d | 0d | Meja ukur; pak Ali; multiplex [1 lembar] | 13.33h |
| 14 | 2.1.2 | Potong | 300min | 2007-06-04 | 2007-06-05 | 13FF+30min, 4 | 2007-06-04 | 2007-06-05 | 300min | 0.44d |  | M. RAS; pak Bom | 10h |
| 15 | 2.1.3 | Penyikuan | 500min | 2007-06-05 | 2007-06-06 | 14SS+30min, 8 | 2007-06-04 | 2007-06-05 | 500min | 0d |  | M. Jointer; pak Cus | 14.67h |
| 16 | 2.2 | **Komponen Y** | 2.46d | 2007-06-05 | 2007-06-07 |  | 2007-06-05 | 2007-06-08 | 2.76d | 0d |  |  | 44.89h |
| 17 | 2.2.1 | Ukur komponen | 400min | 2007-06-05 | 2007-06-06 | 13 | 2007-06-05 | 2007-06-06 | 400min | 0.7d | 0d | Meja ukur; pak Ali; kayu sungkai [1 batang] | 13.33h |
| 18 | 2.2.2 | Penyikuan | 1066.7min | 2007-06-06 | 2007-06-07 | 17SS+15min, 15 | 2007-06-05 | 2007-06-08 | 1066.7min | 0d |  | M. Jointer; pak Cus | 31.56h |
| 19 | 2.3 | **Produk ZZZ** | 0.62d | 2007-06-07 | 2007-06-08 |  | 2007-06-07 | 2007-06-08 | 0.62d | 4.01d |  |  | 10h |
| 20 | 2.3.1 | Rakit dan inspeksi | 300min | 2007-06-07 | 2007-06-08 | 17FF+15min, 18FF+15min | 2007-06-07 | 2007-06-08 | 300min | 4.01d |  | Meja rakit; pak Dul; lem, paku [1 kg] | 10h |
| 21 | 3 | **Batch 3 (20 unit)** | 3.91d | 2007-06-06 | 2007-06-11 |  | 2007-06-04 | 2007-06-08 | 3.63d | 0.79d |  |  | 98.9h |
| 22 | 3.1 | **Komponen X** | 2.67d | 2007-06-06 | 2007-06-09 |  | 2007-06-04 | 2007-06-05 | 1.38d | 0d |  |  | 40h |
| 23 | 3.1.1 | Ukur komponen | 400min | 2007-06-06 | 2007-06-07 | 17 | 2007-06-04 | 2007-06-05 | 400min | 0.79d | 0d | Meja ukur; pak Ali; multiplex [1 lembar] | 13.33h |
| 24 | 3.1.2 | Potong | 300min | 2007-06-06 | 2007-06-07 | 23FF+30min, 14 | 2007-06-04 | 2007-06-05 | 300min | 1.29d | 1.04d | M. RAS; pak Bom | 10h |
| 25 | 3.1.3 | Penyikuan | 500min | 2007-06-08 | 2007-06-09 | 24SS+30min, 18 | 2007-06-04 | 2007-06-05 | 500min | 0d |  | M. Jointer; pak Cus | 16.67h |

| ID | WBS | Task | Duration | Start | Finish | Predecessors | Baseline start | Baseline finish | Baseline duration | Total slack | Free slack | Resources | Work |
| --- | --- | --- | --- | --- | --- | --- | --- | --- | --- | --- | --- | --- | --- |
| 26 | 3.2 | **Komponen Y** | 3.05d | 2007-06-07 | 2007-06-11 |  | 2007-06-05 | 2007-06-08 | 2.76d | 0d |  |  | 48.9h |
| 27 | 3.2.1 | Ukur komponen | 400min | 2007-06-07 | 2007-06-08 | 23 | 2007-06-05 | 2007-06-06 | 400min | 0.79d | 0d | Meja ukur; pak Ali; kayu sungkai [1 batang] | 13.33h |
| 28 | 3.2.2 | Penyikuan | 1066.7min | 2007-06-08 | 2007-06-11 | 25SS+15min, 27SS+15min | 2007-06-05 | 2007-06-08 | 1066.7min | 0d |  | M. Jointer; pak Cus | 35.57h |
| 29 | 3.3 | **Produk ZZZ** | 0.62d | 2007-06-11 | 2007-06-11 |  | 2007-06-07 | 2007-06-08 | 0.62d | 1.75d |  |  | 10h |
| 30 | 3.3.1 | Rakit dan inspeksi | 300min | 2007-06-11 | 2007-06-11 | 27FF+15min, 28FF+15min | 2007-06-07 | 2007-06-08 | 300min | 1.75d |  | Meja rakit; pak Dul; lem, paku [1 kg] | 10h |
| 31 | 4 | **Batch 4 (20 unit)** | 4d | 2007-06-08 | 2007-06-13 |  | 2007-06-04 | 2007-06-08 | 3.63d | 0d |  |  | 92.89h |
| 32 | 4.1 | **Komponen X** | 3d | 2007-06-08 | 2007-06-12 |  | 2007-06-04 | 2007-06-05 | 1.38d | 0d |  |  | 38h |
| 33 | 4.1.1 | Ukur komponen | 400min | 2007-06-08 | 2007-06-09 | 27 | 2007-06-04 | 2007-06-05 | 400min | 1.38d | 0d | Meja ukur; pak Ali; multiplex [1 lembar] | 13.33h |
| 34 | 4.1.2 | Potong | 300min | 2007-06-08 | 2007-06-09 | 33FF+30min, 24 | 2007-06-04 | 2007-06-05 | 300min | 1.88d |  | M. RAS; pak Bom | 10h |
| 35 | 4.1.3 | Penyikuan | 500min | 2007-06-11 | 2007-06-12 | 34SS+30min, 28 | 2007-06-04 | 2007-06-05 | 500min | 0d |  | M. Jointer; pak Cus | 14.67h |
| 36 | 4.2 | **Komponen Y** | 3.13d | 2007-06-09 | 2007-06-13 |  | 2007-06-05 | 2007-06-08 | 2.76d | 0d |  |  | 44.89h |
| 37 | 4.2.1 | Ukur komponen | 400min | 2007-06-09 | 2007-06-11 | 33 | 2007-06-05 | 2007-06-06 | 400min | 1.38d |  | Meja ukur; pak Ali; kayu sungkai [1 batang] | 13.33h |
| 38 | 4.2.2 | Penyikuan | 1066.7min | 2007-06-11 | 2007-06-13 | 35SS+15min, 37SS+15min | 2007-06-05 | 2007-06-08 | 1066.7min | 0d |  | M. Jointer; pak Cus | 31.56h |
| 39 | 4.3 | **Produk ZZZ** | 0.62d | 2007-06-13 | 2007-06-13 |  | 2007-06-07 | 2007-06-08 | 0.62d | 0d |  |  | 10h |
| 40 | 4.3.1 | Rakit dan inspeksi | 300min | 2007-06-13 | 2007-06-13 | 37FF+15min, 38FF+15min | 2007-06-07 | 2007-06-08 | 300min | 0d |  | Meja rakit; pak Dul; lem, paku [1 kg] | 10h |
